# Program Kerja Fasa Pra-Pembinaan PAP (Tanpa Pindaan)

Schedule from MS Project, 2018-01-01 to 2019-01-04.
Unit Amalan Terbaik, BPPK, CPAB

## Calendars

- Standard: Mon-Fri 08:00-12:00, 13:00-17:00; Sat-Sun off.

## Schedule

| ID | WBS | Task | Type | Duration | Start | Finish | Predecessors | Total slack |
| --- | --- | --- | --- | --- | --- | --- | --- | --- |
| 1 | 1 | **Program Kerja Fasa Pra-Pembinaan Konvensional (Perunding)** |  | 265d | 2018-01-01 | 2019-01-04 |  | 0d |
| 2 | 1.1 | Mula Pembinaan | milestone | 0d | 2018-01-01 | 2018-01-01 |  | 0d |
| 3 | 1.2 | **Perancangan Pelaksanaan Projek** |  | 112d | 2018-01-01 | 2018-06-05 |  | 0d |
| 4 | 1.2.1 | Rancang Strategi Pelaksanaan |  | 1d | 2018-01-01 | 2018-01-01 | 2 | 0d |
| 5 | 1.2.2 | Terima Arahan Pelaksanaan dan Brif Projek |  | 3d | 2018-01-02 | 2018-01-04 | 4 | 0d |
| 6 | 1.2.3 | Lantik HOPT |  | 1d | 2018-01-05 | 2018-01-05 | 5 | 0d |
| 7 | 1.2.4 | Laksana ACAT |  | 1d | 2018-01-08 | 2018-01-08 | 6 | 0d |
| 8 | 1.2.5 | Lantik HODT |  | 1d | 2018-01-09 | 2018-01-09 | 7 | 0d |
| 9 | 1.2.6 | Laksana GN1 |  | 1d | 2018-01-10 | 2018-01-10 | 8 | 0d |
| 10 | 1.2.7 | Laksana Semakan Brif 01-1, Verifikasi Harta Pelanggan dan Analisis Sumber Manusia |  | 3d | 2018-01-11 | 2018-01-15 | 9 | 0d |
| 11 | 1.2.8 | Lantik Perunding |  | 40d | 2018-01-16 | 2018-03-12 | 10 | 0d |
| 12 | 1.2.9 | Sedia Rekabentuk Konsep |  | 40d | 2018-03-13 | 2018-05-07 | 11 | 0d |
| 13 | 1.2.10 | Sedia Kos Anggaran Awalan |  | 3d | 2018-05-08 | 2018-05-10 | 12 | 0d |
| 14 | 1.2.11 | Sedia Pelan Kualiti / RMP |  | 3d | 2018-05-08 | 2018-05-10 | 12 | 16d |
| 15 | 1.2.12 | Kajian Semula Rekabentuk Konsep |  | 3d | 2018-05-08 | 2018-05-10 | 12 | 0d |
| 16 | 1.2.13 | Laksana VE |  | 5d | 2018-05-11 | 2018-05-17 | 13, 15 | 0d |
| 17 | 1.2.14 | Pengesahan Brif Projek, Rekabentuk Konsep dan Kos Awalan |  | 1d | 2018-06-01 | 2018-06-01 | 16FS+10d | 0d |
| 18 | 1.2.15 | Pendaftaran Maklumat dalam SKALA |  | 1d | 2018-06-04 | 2018-06-04 | 14, 17 | 0d |
| 19 | 1.2.16 | Laksana GN2 |  | 1d | 2018-06-05 | 2018-06-05 | 18 | 0d |
| 20 | 1.2.17 | Siap Perancangan | milestone | 0d | 2018-06-05 | 2018-06-05 | 19 | 0d |
| 21 | 1.3 | **Rekabentuk** |  | 78d | 2018-06-06 | 2018-09-21 |  | 0d |
| 22 | 1.3.1 | **Rekabentuk Awalan** |  | 43d | 2018-06-06 | 2018-08-03 |  | 0d |
| 23 | 1.3.1.1 | Sedia Rekabentuk Awalan |  | 20d | 2018-06-06 | 2018-07-03 | 20 | 0d |
| 24 | 1.3.1.2 | Kajian Semula Rekabentuk Awalan |  | 3d | 2018-07-04 | 2018-07-06 | 23 | 0d |
| 25 | 1.3.1.3 | Kelulusan Merancang | milestone | 0d | 2018-08-03 | 2018-08-03 | 24FS+20d | 33d |
| 26 | 1.3.1.4 | Persetujuan Pelanggan | milestone | 0d | 2018-08-03 | 2018-08-03 | 24FS+20d | 33d |

| ID | WBS | Task | Type | Duration | Start | Finish | Predecessors | Total slack |
| --- | --- | --- | --- | --- | --- | --- | --- | --- |
| 27 | 1.3.2 | **Rekabentuk Terperinci** |  | 55d | 2018-07-09 | 2018-09-21 |  | 0d |
| 28 | 1.3.2.1 | Rekabentuk Terperinci |  | 30d | 2018-07-09 | 2018-08-17 | 24 | 0d |
| 29 | 1.3.2.2 | Kajian Semula Rekabentuk |  | 3d | 2018-08-20 | 2018-08-22 | 28 | 0d |
| 30 | 1.3.2.3 | Verifikasi Rekabentuk |  | 3d | 2018-08-23 | 2018-08-27 | 29 | 0d |
| 31 | 1.3.2.4 | Laksana VE |  | 5d | 2018-08-28 | 2018-09-03 | 30 | 0d |
| 32 | 1.3.2.5 | Pindaan Rekabentuk (Jika Berkenaan) |  | 5d | 2018-09-04 | 2018-09-10 | 31 | 0d |
| 33 | 1.3.2.6 | Kelulusan Rekabentuk dan Spesifikasi |  | 1d | 2018-09-11 | 2018-09-11 | 32 | 0d |
| 34 | 1.3.2.7 | Serahan kepada HOPT |  | 1d | 2018-09-12 | 2018-09-12 | 33 | 0d |
| 35 | 1.3.2.8 | Serahan kepada Pejabat Pemanggil Tender |  | 1d | 2018-09-20 | 2018-09-20 | 25, 26, 34FS+5d | 0d |
| 36 | 1.3.2.9 | Laksana GN3 |  | 1d | 2018-09-21 | 2018-09-21 | 35 | 0d |
| 37 | 1.3.3 | Siap Rekabentuk | milestone | 0d | 2018-09-21 | 2018-09-21 | 36 | 0d |
| 38 | 1.4 | **Perolehan** |  | 75d | 2018-09-24 | 2019-01-04 |  | 0d |
| 39 | 1.4.1 | Sedia Dokumen Tawaran |  | 15d | 2018-09-24 | 2018-10-12 | 37 | 0d |
| 40 | 1.4.2 | Tawaran/Iklan |  | 20d | 2018-10-15 | 2018-11-09 | 39 | 0d |
| 41 | 1.4.3 | Penilaian Tawaran |  | 15d | 2018-11-12 | 2018-11-30 | 40 | 0d |
| 42 | 1.4.4 | Lembaga Tender |  | 10d | 2018-12-03 | 2018-12-14 | 41 | 0d |
| 43 | 1.4.5 | ATDA & Sah Peruntukan |  | 10d | 2018-12-17 | 2018-12-28 | 42 | 0d |
| 44 | 1.4.6 | Surat Setuju Terima Tender |  | 5d | 2018-12-31 | 2019-01-04 | 43 | 0d |
| 45 | 1.5 | Tamat Pra-Pembinaan | milestone | 0d | 2019-01-04 | 2019-01-04 | 44 | 0d |
